# Online Teaching Tools Project Plan

Schedule from MS Project, 2020-02-24 to 2020-05-06.

## Calendars

- Standard: Mon-Fri 08:00-12:00, 13:00-17:00; Sat-Sun off.

## Resources

| Resource |
| --- |
| Yi Jin |
| Yongde |
| Yin Gong |
| Jin Yi |

## Schedule

| ID | WBS | Task | Type | Duration | Start | Finish | Predecessors | Resources | Work |
| --- | --- | --- | --- | --- | --- | --- | --- | --- | --- |
| 1 | 1 | Media server set up | manual | 3d | 2020-02-24 | 2020-02-25 |  | Yi Jin | 24h |
| 2 | 2 | **User can Login** |  | 3d | 2020-02-24 | 2020-02-25 |  | Yongde | 144h |
| 3 | 2.1 | User interface design: Login page(including HTML, JS,CSS ) | manual | 5d | 2020-02-26 | 2020-03-03 | 1 | Yin Gong | 40h |
| 4 | 2.2 | Spring handler (Start-page handler and Login-checking handler ) | manual | 5d | 2020-02-26 | 2020-03-03 | 1 | Yongde | 40h |
| 5 | 2.3 | My SQL design(User table) | manual | 5d | 2020-02-26 | 2020-03-03 | 1 | Jin Yi | 40h |
| 6 | 3 | **User can upload (delete) videos** |  | 15d | 2020-02-27 | 2020-03-17 |  |  | 240h |
| 7 | 3.1 | User interface design: Uploading-videos page (including HTML, JS, CSS) | manual | 10d | 2020-03-04 | 2020-03-17 | 3 | Yin Gong | 80h |
| 8 | 3.2 | Spring handler (Uploading-video handler) | manual | 10d | 2020-03-04 | 2020-03-17 | 4 | Yongde | 80h |
| 9 | 3.3 | My SQL design(Video table ) | manual | 10d | 2020-03-04 | 2020-03-17 | 5 | Jin Yi | 80h |
| 10 | 4 | **User can searching videos** |  | 15d | 2020-03-05 | 2020-03-24 |  |  | 120h |
| 11 | 4.1 | User interface design: Searching-videos page (including HTML, JS, CSS) | manual | 5d | 2020-03-18 | 2020-03-24 | 7 | Yin Gong | 40h |
| 12 | 4.2 | Spring handler (Searching-video hander ) | manual | 5d | 2020-03-18 | 2020-03-24 | 8 | Yongde | 40h |
| 13 | 4.3 | My SQL design(Video) and SQL query design | manual | 5d | 2020-03-18 | 2020-03-24 | 9 | Yi Jin | 40h |
| 14 | 5 | **User can watch a video** |  | 8d | 2020-03-19 | 2020-03-27 |  |  | 48h |
| 15 | 5.1 | User interface design:Watching-videos page (including HTML, JS, CSS) | manual | 3d | 2020-03-25 | 2020-03-27 | 13 | Yin Gong | 24h |
| 16 | 5.2 | Spring handler (Watching-video handler) | manual | 3d | 2020-03-25 | 2020-03-27 | 13 | Yongde | 24h |
| 17 | 6 | **User can add evaluations to a video** |  | 12d | 2020-03-26 | 2020-04-09 |  |  | 216h |
| 18 | 6.1 | User interface design: Evaluating pages (including HTML, JS, CSS) | manual | 9d | 2020-03-30 | 2020-04-09 | 16 | Yin Gong | 72h |
| 19 | 6.2 | Spring handler (Evaluation hander) | manual | 9d | 2020-03-30 | 2020-04-09 | 16 | Yongde | 72h |
| 20 | 6.3 | MySQL design (Rating analysis table and Four-rubric table) | manual | 9d | 2020-03-30 | 2020-04-09 | 16 | Yi Jin | 72h |
| 21 | 7 | **Test and remediate** |  | 19d | 2020-03-31 | 2020-04-23 |  |  | 240h |
| 22 | 7.1 | Test and remediate | manual | 10d | 2020-04-10 | 2020-04-23 | 18 | Yin Gong | 80h |
| 23 | 7.2 | Test and remediate | manual | 10d | 2020-04-10 | 2020-04-23 | 19 | Yongde | 80h |
| 24 | 7.3 | Test and remediate | manual | 10d | 2020-04-10 | 2020-04-23 | 20 | Jin Yi | 80h |

| ID | WBS | Task | Type | Duration | Start | Finish | Predecessors | Resources | Work |
| --- | --- | --- | --- | --- | --- | --- | --- | --- | --- |
| 25 | 8 | **Deployment** |  | 19d | 2020-04-13 | 2020-05-06 |  |  | 216h |
| 26 | 8.1 | Deployment | manual | 9d | 2020-04-24 | 2020-05-06 | 22 | Yin Gong | 72h |
| 27 | 8.2 | Deployment | manual | 9d | 2020-04-24 | 2020-05-06 | 23 | Yongde | 72h |
| 28 | 8.3 | Deployment | manual | 9d | 2020-04-24 | 2020-05-06 | 24 | Yi Jin | 72h |
