# robot

Schedule from MS Project, 2020-03-17 to 2020-09-28.

## Calendars

- Standard: Mon-Fri 08:00-12:00, 13:00-17:00; Sat-Sun off.

## Schedule

| ID | WBS | Task | Duration | Start | Finish | Predecessors | Total slack | Free slack | Constraint |
| --- | --- | --- | --- | --- | --- | --- | --- | --- | --- |
| 1 | 1 | a. System Specification | 2w | 2020-03-17 | 2020-03-30 |  | 0d |  | start no earlier than 2020-03-17 |
| 2 | 2 | b. Analysis | 2w | 2020-03-31 | 2020-04-13 | 1 | 0d |  |  |
| 3 | 3 | c. SRS | 2w | 2020-04-14 | 2020-04-27 | 2 | 0d |  |  |
| 4 | 4 | **d. Top Level Design** | 30d | 2020-04-28 | 2020-06-08 | 3 | 0d |  |  |
| 5 | 4.1 | General Joint Class | 4d | 2020-04-28 | 2020-05-01 | 3 | 0d |  |  |
| 6 | 4.2 | General Interface Class | 5d | 2020-05-04 | 2020-05-08 | 5 | 0d |  |  |
| 7 | 4.3 | Joint-Specific Designs | 14d | 2020-05-11 | 2020-05-28 | 6 | 0d |  |  |
| 8 | 4.4 | Real Time OS Allocation | 7d | 2020-05-29 | 2020-06-08 | 7 | 0d |  |  |
| 9 | 5 | **e. TLDD** | 3d? | 2020-06-09 | 2020-06-11 | 8 | 7d |  |  |
| 10 | 5.1 | Planning Meeting | 2d | 2020-06-09 | 2020-06-10 | 8 | 7d | 0d |  |
| 11 | 5.2 | Write Document | 1d? | 2020-06-11 | 2020-06-11 | 10 | 7d |  |  |
| 12 | 6 | f. HW/SW Interface | 2w | 2020-06-09 | 2020-06-22 | 4 | 0d |  |  |
| 13 | 7 | g. Joint Class | 2w | 2020-06-23 | 2020-07-06 | 9, 12 | 0d |  |  |
| 14 | 8 | h. Joint Support Classes | 2w | 2020-07-07 | 2020-07-20 | 13 | 0d |  |  |
| 15 | 9 | I. Application Class | 3w | 2020-06-23 | 2020-07-13 | 9, 12 | 5d | 0d |  |
| 16 | 10 | j. Wast Object Detailed Design | 1w | 2020-07-21 | 2020-07-27 | 14, 15 | 10d | 0d |  |
| 17 | 11 | k. Waist Object Code | 1w | 2020-07-28 | 2020-08-03 | 16 | 10d |  |  |
| 18 | 12 | l. Shoulder Object Detailed Design | 1w | 2020-07-21 | 2020-07-27 | 14, 15 | 10d | 0d |  |
| 19 | 13 | m. Shoulder Object Code | 1w | 2020-07-28 | 2020-08-03 | 18 | 10d |  |  |
| 20 | 14 | n. Elbow Object Detailed Design | 1w | 2020-07-21 | 2020-07-27 | 14, 15 | 10d | 0d |  |
| 21 | 15 | o. Elbow Object Code | 1w | 2020-07-28 | 2020-08-03 | 20 | 10d |  |  |
| 22 | 16 | p. Wrist Turn Object Detailed Design | 1w | 2020-07-21 | 2020-07-27 | 14, 15 | 0d |  |  |
| 23 | 17 | q. Wrist Turn Object Code | 1w | 2020-07-28 | 2020-08-03 | 22 | 10d |  |  |
| 24 | 18 | r. Wrist Bend Object Detailed Design | 1w | 2020-07-28 | 2020-08-03 | 14, 15, 22 | 0d |  |  |
| 25 | 19 | s. Wrist Bend Object Code | 1w | 2020-08-04 | 2020-08-10 | 24 | 5d |  |  |
| 26 | 20 | t. Grasp Object Detailed Design | 1w | 2020-08-04 | 2020-08-10 | 15, 14, 24 | 0d |  |  |
| 27 | 21 | u. Grasp Object Code | 1w | 2020-08-11 | 2020-08-17 | 26 | 0d |  |  |
| 28 | 22 | v. Application Object Code | 4w | 2020-07-14 | 2020-08-10 | 15 | 5d |  |  |
| 29 | 23 | w. Acceptance Test Plan | 1w | 2020-06-09 | 2020-06-15 | 4 | 60d |  |  |
| 30 | 24 | x. Integration | 3w | 2020-08-18 | 2020-09-07 | 17, 19, 21, 23, 25, 27, 28 | 0d |  |  |
| 31 | 25 | y. Acceptance Test | 2w | 2020-09-08 | 2020-09-21 | 29, 30 | 0d |  |  |
| 32 | 26 | z. Final Review | 1w | 2020-09-22 | 2020-09-28 | 31 | 0d |  |  |
